# NSF Aloha MARS sedementation 07

Schedule from MS Project, 2008-01-14 to 2010-07-16.
MBARI

## Calendars

- Standard: Mon-Fri 08:00-12:00, 13:00-17:00; Sat-Sun off.

## Resources

| Resource |
| --- |
| ME |
| SE |
| CIP EE |
| CIP Machinist |
| CIP EE Tech |
| CIP ME Tech |
| CIP Welder Tech |
| ME Tech |
| EE1 |
| EE2 |

## Schedule

| ID | WBS | Task | Duration | Start | Finish | Predecessors | Total slack | Free slack | Constraint | Resources | Work |
| --- | --- | --- | --- | --- | --- | --- | --- | --- | --- | --- | --- |
| 1 | 1 | **Aloha Sedementation Experiment** | 655d? | 2008-01-14 | 2010-07-16 |  | 0d |  |  |  | 4632h |
| 2 | 1.1 | **Base** | 174d? | 2008-01-14 | 2008-09-11 |  | 325d |  | start no earlier than 2008-01-12 |  | 1840h |
| 3 | 1.1.1 | **Frame** | 34d? | 2008-01-14 | 2008-02-28 |  | 325d |  |  |  | 272h |
| 4 | 1.1.1.1 | Design Frame | 13d? | 2008-01-14 | 2008-01-30 |  | 325d | 0d | finish no earlier than 2008-01-06 | ME | 104h |
| 5 | 1.1.1.2 | order transponder | 1d? | 2008-01-31 | 2008-01-31 | 4 | 325d | 0d |  | ME | 8h |
| 6 | 1.1.1.3 | locate and secure material | 2d? | 2008-02-01 | 2008-02-04 | 5 | 621d | 0d |  | CIP ME Tech | 16h |
| 7 | 1.1.1.4 | cut and drill sections | 2d? | 2008-02-05 | 2008-02-06 | 6 | 621d | 0d |  | CIP ME Tech | 16h |
| 8 | 1.1.1.5 | weld up | 15d? | 2008-02-07 | 2008-02-27 | 7 | 621d | 0d |  | CIP Welder Tech | 120h |
| 9 | 1.1.1.6 | add brackets | 1d? | 2008-02-28 | 2008-02-28 | 8 | 621d |  |  | CIP ME Tech | 8h |
| 10 | 1.1.2 | **Base Electronics** | 157.5d? | 2008-01-14 | 2008-08-20 |  | 339d |  |  |  | 992h |
| 11 | 1.1.2.1 | design base electronics | 30d? | 2008-01-14 | 2008-02-22 |  | 376.67d | 0d | start no earlier than 2008-01-06 | EE1 [50%] | 120h |
| 12 | 1.1.2.2 | specify and order electrical components | 6.67d? | 2008-02-25 | 2008-03-04 | 11 | 376.67d | 0d |  | EE1 [50%]; CIP EE Tech | 80h |
| 13 | 1.1.2.3 | specify and order U/W connectors | 6.67d? | 2008-03-04 | 2008-03-13 | 12 | 376.67d | 0d |  | EE1 [50%]; CIP EE Tech | 80h |
| 14 | 1.1.2.4 | fabricate and ship U/W connectors | 60d | 2008-03-13 | 2008-06-05 | 13 | 551.67d |  |  |  |  |
| 15 | 1.1.2.5 | Order sphere casting and machining | 1d? | 2008-02-01 | 2008-02-01 | 5 | 325d | 0d |  | ME | 8h |
| 16 | 1.1.2.6 | sphere casting | 60d | 2008-02-04 | 2008-04-25 | 15 | 325d | 0d |  |  |  |
| 17 | 1.1.2.7 | sphere machining | 20d | 2008-04-28 | 2008-05-23 | 16 | 325d | 0d |  |  |  |
| 18 | 1.1.2.8 | order current meter | 2d? | 2008-05-26 | 2008-05-27 | 17, 13 | 325d | 0d |  | EE2 [50%] | 8h |
| 19 | 1.1.2.9 | current meter fab and shipping | 45d | 2008-05-28 | 2008-07-29 | 18 | 497.5d | 0d |  |  |  |
| 20 | 1.1.2.10 | Wire up and test | 15.5d? | 2008-07-30 | 2008-08-20 | 19 | 497.5d |  |  | CIP EE Tech; EE1 | 248h |
| 21 | 1.1.2.11 | Develop control software | 56d? | 2008-01-14 | 2008-03-31 |  | 556d | 231d | start no earlier than 2008-01-06 | SE | 448h |
| 22 | 1.1.3 | **Time Lapse Camera System** | 37d? | 2008-05-28 | 2008-07-17 |  | 325d |  |  |  | 208h |
| 23 | 1.1.3.1 | Specify and order cameras ( Coordinate with WHOI) | 4d? | 2008-05-28 | 2008-06-02 | 18 | 325d | 0d |  | EE1 [50%] | 16h |
| 24 | 1.1.3.2 | Specify and order strobes | 8d? | 2008-06-03 | 2008-06-12 | 23 | 325d | 0d |  | EE2 [50%] | 32h |
| 25 | 1.1.3.3 | Design mounting brackets for cameras and strobes | 2d? | 2008-06-13 | 2008-06-16 | 24 | 325d | 0d |  | ME | 16h |
| 26 | 1.1.3.4 | specify and order strobe j-box connectors | 1d? | 2008-06-17 | 2008-06-17 | 25, 15 | 325d | 0d |  | ME | 8h |
| 27 | 1.1.3.5 | Fabricate strobe j-boxes | 2d? | 2008-06-18 | 2008-06-19 | 26 | 478d | 0d |  | CIP Machinist | 16h |
| 28 | 1.1.3.6 | Develop camera interface | 10d? | 2008-06-20 | 2008-07-03 | 27 | 478d | 0d |  | EE1 [50%] | 40h |
| 29 | 1.1.3.7 | wire up and test | 5d? | 2008-07-04 | 2008-07-10 | 28 | 478d | 0d |  | CIP EE Tech | 40h |
| 30 | 1.1.3.8 | assemble and install j-box connectors | 5d? | 2008-07-11 | 2008-07-17 | 29 | 478d | 153d |  | CIP EE Tech | 40h |

| ID | WBS | Task | Duration | Start | Finish | Predecessors | Total slack | Free slack | Resources | Work |
| --- | --- | --- | --- | --- | --- | --- | --- | --- | --- | --- |
| 31 | 1.1.4 | **Sed. Sensor (2 units)** | 62d? | 2008-06-18 | 2008-09-11 |  | 325d |  |  | 368h |
| 32 | 1.1.4.1 | Order (2) McLane Parfluxs | 2d? | 2008-06-18 | 2008-06-19 | 26 | 325d | 0d | ME [50%] | 8h |
| 33 | 1.1.4.2 | McLane fabrication | 60d | 2008-06-20 | 2008-09-11 | 32 | 481d |  |  |  |
| 34 | 1.1.4.3 | Specify camera and light | 5d? | 2008-06-20 | 2008-06-26 | 32 | 536d |  | ME | 40h |
| 35 | 1.1.4.4 | Order camera and light | 4d? | 2008-06-20 | 2008-06-25 | 32 | 325d | 0d | EE1 [50%] | 16h |
| 36 | 1.1.4.5 | Sed sensor mods (stepper, fluorometers, halls) | 10d? | 2008-06-26 | 2008-07-09 | 35 | 325d | 0d | EE2 [50%] | 40h |
| 37 | 1.1.4.6 | Sensor calibration and validation | 10d? | 2008-07-10 | 2008-07-23 | 36 | 325d | 0d | EE2 [50%] | 40h |
| 38 | 1.1.4.7 | Design imaging stage for Parflux | 10d? | 2008-07-24 | 2008-08-06 | 37 | 325d | 0d | ME | 80h |
| 39 | 1.1.4.8 | Fabricate imaging stage components (~6 parts) | 3d? | 2008-08-07 | 2008-08-11 | 38 | 441d | 0d | CIP Machinist | 24h |
| 40 | 1.1.4.9 | Build Sed. Sensor | 10d? | 2008-08-12 | 2008-08-25 | 39 | 441d | 0d | CIP ME Tech | 80h |
| 41 | 1.1.4.10 | Wire up and test | 10d? | 2008-08-26 | 2008-09-08 | 40 | 441d | 116d | EE2 [50%] | 40h |
| 42 | 1.2 | **Benthic Cable** | 73d? | 2008-08-07 | 2008-11-17 |  | 325d |  |  | 224h |
| 43 | 1.2.1 | Design winch | 10d? | 2008-08-07 | 2008-08-20 | 38 | 325d | 0d | ME | 80h |
| 44 | 1.2.2 | order material | 1d? | 2008-08-21 | 2008-08-21 | 43 | 325d | 0d | ME | 8h |
| 45 | 1.2.3 | order ODI connector and cable | 1d? | 2008-08-22 | 2008-08-22 | 44 | 325d | 0d | ME | 8h |
| 46 | 1.2.4 | order football floats | 1d? | 2008-08-25 | 2008-08-25 | 45 | 325d | 0d | ME | 8h |
| 47 | 1.2.5 | connector and cable fabrication | 60d | 2008-08-26 | 2008-11-17 | 46 | 434d |  |  |  |
| 48 | 1.2.6 | waterjet plates | 2d? | 2008-08-26 | 2008-08-27 | 46 | 479d | 0d | CIP Machinist | 16h |
| 49 | 1.2.7 | cut drum | 1d? | 2008-08-28 | 2008-08-28 | 48 | 479d | 0d | CIP Machinist | 8h |
| 50 | 1.2.8 | fabricate winch | 8d? | 2008-08-29 | 2008-09-09 | 49 | 479d | 0d | CIP Machinist | 64h |
| 51 | 1.2.9 | Assemble and test winch | 4d? | 2008-09-10 | 2008-09-15 | 50 | 479d |  | CIP ME Tech | 32h |
| 52 | 1.3 | **Riser Cable** | 61d? | 2008-08-26 | 2008-11-18 |  | 325d |  |  | 104h |
| 53 | 1.3.1 | Specify and order cable | 1d? | 2008-08-26 | 2008-08-26 | 46 | 325d | 0d | ME | 8h |
| 54 | 1.3.2 | fabricate and ship cable | 60d | 2008-08-27 | 2008-11-18 | 53 | 433d |  |  |  |
| 55 | 1.3.3 | design mechanical terminations with slip rings | 7d? | 2008-08-27 | 2008-09-04 | 53 | 325d | 0d | ME | 56h |
| 56 | 1.3.4 | fabricate mech. Term. | 2d? | 2008-09-05 | 2008-09-08 | 55 | 438d | 0d | CIP Machinist | 16h |
| 57 | 1.3.5 | install slip rings | 3d? | 2008-09-09 | 2008-09-11 | 56 | 438d | 113d | CIP ME Tech | 24h |

| ID | WBS | Task | Duration | Start | Finish | Predecessors | Total slack | Free slack | Resources | Work |
| --- | --- | --- | --- | --- | --- | --- | --- | --- | --- | --- |
| 58 | 1.4 | **Pelagic Platform** | 118d? | 2008-09-05 | 2009-02-17 |  | 325d |  |  | 600h |
| 59 | 1.4.1 | Design Pelagic Platform | 6d? | 2008-09-05 | 2008-09-12 | 55 | 325d | 0d | ME | 48h |
| 60 | 1.4.2 | Specify and order cable | 1d? | 2008-09-15 | 2008-09-15 | 59 | 325d | 0d | ME | 8h |
| 61 | 1.4.3 | cable fabrication and shipping | 60d | 2008-09-16 | 2008-12-08 | 60 | 419d |  |  |  |
| 62 | 1.4.4 | Specify and order slip rings | 1d? | 2008-09-16 | 2008-09-16 | 60 | 325d | 0d | ME | 8h |
| 63 | 1.4.5 | slip ring fabrication and shipping | 60d | 2008-09-17 | 2008-12-09 | 62 | 418d |  |  |  |
| 64 | 1.4.6 | Specify and order syntatic floam module | 1d? | 2008-09-17 | 2008-09-17 | 62 | 325d | 0d | ME | 8h |
| 65 | 1.4.7 | fabricate and ship syntatic foam module | 1d? | 2008-09-18 | 2008-09-18 | 64 | 325d | 0d |  |  |
| 66 | 1.4.8 | specify and order ODI connectors | 1d? | 2008-09-19 | 2008-09-19 | 65, 64 | 325d | 0d | ME | 8h |
| 67 | 1.4.9 | fabricate and ship ODI connectors | 60d | 2008-09-22 | 2008-12-12 | 66 | 415d |  |  |  |
| 68 | 1.4.10 | Design upper electronics PV | 6d? | 2008-09-22 | 2008-09-29 | 66 | 325d | 0d | ME | 48h |
| 69 | 1.4.11 | fabricate PV | 5d? | 2008-09-30 | 2008-10-06 | 68 | 325d | 0d | CIP Machinist | 40h |
| 70 | 1.4.12 | fabricate platform frame | 10d? | 2008-10-07 | 2008-10-20 | 69 | 325d | 0d | CIP Machinist | 80h |
| 71 | 1.4.13 | install Sed sensor, PV, foam, slip ring | 12d? | 2008-10-21 | 2008-11-05 | 70 | 325d | 0d | ME Tech | 96h |
| 72 | 1.4.14 | Design pelagic platform electronics | 20d? | 2008-11-06 | 2008-12-03 | 71, 36 | 325d | 0d | EE2 [50%] | 80h |
| 73 | 1.4.15 | specify and order electrical components | 2d? | 2008-12-04 | 2008-12-05 | 72 | 325d | 0d | EE1 [50%] | 8h |
| 74 | 1.4.16 | specify and order U/W connectors | 2d? | 2008-12-08 | 2008-12-09 | 73 | 325d | 0d | EE1 [50%] | 8h |
| 75 | 1.4.17 | fabricate and ship U/W connectors | 30d | 2008-12-10 | 2009-01-20 | 74 | 325d | 0d |  |  |
| 76 | 1.4.18 | assemble pelagic platform | 20d? | 2009-01-21 | 2009-02-17 | 75 | 325d | 0d | ME Tech | 160h |
| 77 | 1.5 | **Test and integration** | 368d? | 2009-02-18 | 2010-07-16 | 76, 57, 41, 30, 21 | 0d |  |  | 1864h |
| 78 | 1.5.1 | **Tank testing** | 15d? | 2009-02-18 | 2009-03-10 |  | 325d | 0d |  | 360h |
| 79 | 1.5.1.1 | ME tasks | 10d? | 2009-02-18 | 2009-03-03 |  | 330d |  | ME | 80h |
| 80 | 1.5.1.2 | EE tasks | 10d? | 2009-02-18 | 2009-03-03 |  | 330d |  | EE1 [50%]; EE2 [50%] | 80h |
| 81 | 1.5.1.3 | SE tasks | 10d? | 2009-02-18 | 2009-03-03 |  | 330d |  | SE | 80h |
| 82 | 1.5.1.4 | Tech tasks | 15d? | 2009-02-18 | 2009-03-10 |  | 325d |  | ME Tech | 120h |

| ID | WBS | Task | Duration | Start | Finish | Predecessors | Total slack | Free slack | Constraint | Resources | Work |
| --- | --- | --- | --- | --- | --- | --- | --- | --- | --- | --- | --- |
| 83 | 1.5.2 | **Deploy on MARS 1** | 5d? | 2009-03-11 | 2009-03-17 | 78 | 325d | 0d |  |  | 160h |
| 84 | 1.5.2.1 | ME tasks | 5d? | 2009-03-11 | 2009-03-17 |  | 325d |  |  | ME | 40h |
| 85 | 1.5.2.2 | EE tasks | 5d? | 2009-03-11 | 2009-03-17 |  | 325d |  |  | EE1 [50%]; EE2 [50%] | 40h |
| 86 | 1.5.2.3 | SE tasks | 5d? | 2009-03-11 | 2009-03-17 |  | 325d |  |  | SE | 40h |
| 87 | 1.5.2.4 | Tech tasks | 5d? | 2009-03-11 | 2009-03-17 |  | 325d |  |  | ME Tech | 40h |
| 88 | 1.5.3 | **Deploy on MARS 2** | 5d? | 2009-03-18 | 2009-03-24 | 83 | 325d | 34d |  |  | 160h |
| 89 | 1.5.3.1 | ME tasks | 5d? | 2009-03-18 | 2009-03-24 |  | 325d |  |  | ME | 40h |
| 90 | 1.5.3.2 | EE tasks | 5d? | 2009-03-18 | 2009-03-24 |  | 325d |  |  | EE1 [50%]; EE2 [50%] | 40h |
| 91 | 1.5.3.3 | SE tasks | 5d? | 2009-03-18 | 2009-03-24 |  | 325d |  |  | SE | 40h |
| 92 | 1.5.3.4 | Tech tasks | 5d? | 2009-03-18 | 2009-03-24 |  | 325d |  |  | ME Tech | 40h |
| 93 | 1.5.4 | **Deploy on Aloha 1** | 18d? | 2009-05-12 | 2009-06-04 | 88 | 291d |  | start no earlier than 2009-05-12 |  | 632h |
| 94 | 1.5.4.1 | **ME tasks** | 18d? | 2009-05-12 | 2009-06-04 |  | 291d |  |  |  | 168h |
| 95 | 1.5.4.1.1 | Travel to WHOI to plan with Jason | 3d? | 2009-05-12 | 2009-05-14 |  | 306d |  |  | ME | 24h |
| 96 | 1.5.4.1.2 | Travel to HA to deploy | 18d? | 2009-05-12 | 2009-06-04 |  | 291d |  |  | ME | 144h |
| 97 | 1.5.4.2 | **EE tasks** | 18d? | 2009-05-12 | 2009-06-04 |  | 291d |  |  |  | 312h |
| 98 | 1.5.4.2.1 | Travel to HA to plan with Aloha | 3d? | 2009-05-12 | 2009-05-14 |  | 306d |  |  | EE1 | 24h |
| 99 | 1.5.4.2.2 | Travel to HA to deploy | 18d | 2009-05-12 | 2009-06-04 |  | 291d |  |  | EE1; EE2 | 288h |
| 100 | 1.5.4.3 | SE tasks | 18d? | 2009-05-12 | 2009-06-04 |  | 291d |  |  | SE | 144h |
| 101 | 1.5.4.4 | Tech tasks | 1d? | 2009-05-12 | 2009-05-12 |  | 308d |  |  | ME Tech | 8h |
| 102 | 1.5.5 | **Deploy on Aloha 2** | 18d? | 2010-06-14 | 2010-07-07 |  | 7d |  | start no earlier than 2010-06-12 |  | 432h |
| 103 | 1.5.5.1 | **ME tasks** | 18d? | 2010-06-14 | 2010-07-07 |  | 7d |  |  |  | 144h |
| 104 | 1.5.5.1.1 | Travel to HA to deploy | 18d? | 2010-06-14 | 2010-07-07 |  | 7d |  |  | ME | 144h |
| 105 | 1.5.5.2 | EE tasks | 18d? | 2010-06-14 | 2010-07-07 |  | 7d |  |  | EE1 | 144h |
| 106 | 1.5.5.3 | SE tasks | 18d? | 2010-06-14 | 2010-07-07 |  | 7d |  |  | SE | 144h |

| ID | WBS | Task | Duration | Start | Finish | Total slack | Constraint | Resources | Work |
| --- | --- | --- | --- | --- | --- | --- | --- | --- | --- |
| 107 | 1.5.6 | **Document and report** | 5d? | 2010-07-12 | 2010-07-16 | 0d | start no earlier than 2010-07-12 |  | 120h |
| 108 | 1.5.6.1 | ME tasks | 5d? | 2010-07-12 | 2010-07-16 | 0d |  | ME | 40h |
| 109 | 1.5.6.2 | EE tasks | 5d? | 2010-07-12 | 2010-07-16 | 0d |  | EE2 | 40h |
| 110 | 1.5.6.3 | SE tasks | 5d? | 2010-07-12 | 2010-07-16 | 0d |  | SE | 40h |
