# Year 1 NSF

Schedule from MS Project, 2007-02-12 to 2008-11-18.
MBARI

## Calendars

- Standard: Mon-Fri 08:00-12:00, 13:00-17:00; Sat-Sun off.

## Resources

| Resource |
| --- |
| ME |
| CIP ME Tech |
| CIP Welder Tech |
| CIP EE Tech |
| CIP EE |
| SE |
| CIP Machinist |
| EE1 |
| EE2 |

## Schedule

| ID | WBS | Task | Duration | Start | Finish | Predecessors | Total slack | Free slack | Constraint | Resources | Work |
| --- | --- | --- | --- | --- | --- | --- | --- | --- | --- | --- | --- |
| 1 | 1 | Year 1 NSF | 1d? | 2007-02-12 | 2007-02-12 |  | 551d |  |  |  |  |
| 2 | 2 | **Aloha Sedementation Experiment** | 240d? | 2007-12-19 | 2008-11-18 |  | 0d |  |  |  | 2248h |
| 3 | 2.1 | **Base** | 174d? | 2007-12-19 | 2008-08-18 |  | 0d |  |  |  | 1840h |
| 4 | 2.1.1 | **Frame** | 34d? | 2007-12-19 | 2008-02-04 |  | 0d |  |  |  | 272h |
| 5 | 2.1.1.1 | Design Frame | 13d? | 2007-12-19 | 2008-01-06 |  | 0d |  | finish no earlier than 2008-01-06 | ME | 104h |
| 6 | 2.1.1.2 | order transponder | 1d? | 2008-01-07 | 2008-01-07 | 5 | 0d |  |  | ME | 8h |
| 7 | 2.1.1.3 | locate and secure material | 2d? | 2008-01-08 | 2008-01-09 | 6 | 206d | 0d |  | CIP ME Tech | 16h |
| 8 | 2.1.1.4 | cut and drill sections | 2d? | 2008-01-10 | 2008-01-11 | 7 | 206d | 0d |  | CIP ME Tech | 16h |
| 9 | 2.1.1.5 | weld up | 15d? | 2008-01-14 | 2008-02-01 | 8 | 206d | 0d |  | CIP Welder Tech | 120h |
| 10 | 2.1.1.6 | add brackets | 1d? | 2008-02-04 | 2008-02-04 | 9 | 206d |  |  | CIP ME Tech | 8h |
| 11 | 2.1.2 | **Base Electronics** | 144.5d? | 2008-01-07 | 2008-07-25 |  | 1d |  |  |  | 992h |
| 12 | 2.1.2.1 | design base electronics | 30d? | 2008-01-07 | 2008-02-15 |  | 38.67d | 0d | start no earlier than 2008-01-06 | EE1 [50%] | 120h |
| 13 | 2.1.2.2 | specify and order electrical components | 6.67d? | 2008-02-18 | 2008-02-26 | 12 | 38.67d | 0d |  | EE1 [50%]; CIP EE Tech | 80h |
| 14 | 2.1.2.3 | specify and order U/W connectors | 6.67d? | 2008-02-26 | 2008-03-06 | 13 | 38.67d | 0d |  | EE1 [50%]; CIP EE Tech | 80h |
| 15 | 2.1.2.4 | fabricate and ship U/W connectors | 60d | 2008-03-06 | 2008-05-29 | 14 | 123.67d |  |  |  |  |
| 16 | 2.1.2.5 | Order sphere casting and machining | 1d? | 2008-01-08 | 2008-01-08 | 6 | 0d |  |  | ME | 8h |
| 17 | 2.1.2.6 | sphere casting | 60d | 2008-01-09 | 2008-04-01 | 16 | 0d |  |  |  |  |
| 18 | 2.1.2.7 | sphere machining | 20d | 2008-04-02 | 2008-04-29 | 17 | 0d |  |  |  |  |
| 19 | 2.1.2.8 | order current meter | 2d? | 2008-04-30 | 2008-05-01 | 14, 18 | 0d |  |  | EE2 [50%] | 8h |
| 20 | 2.1.2.9 | current meter fab and shipping | 45d | 2008-05-02 | 2008-07-03 | 19 | 82.5d | 0d |  |  |  |
| 21 | 2.1.2.10 | Wire up and test | 15.5d? | 2008-07-04 | 2008-07-25 | 20 | 82.5d |  |  | CIP EE Tech; CIP EE | 248h |
| 22 | 2.1.2.11 | Develop control software | 56d? | 2008-01-07 | 2008-03-24 |  | 171d |  | start no earlier than 2008-01-06 | SE | 448h |
| 23 | 2.1.3 | **Time Lapse Camera System** | 37d? | 2008-05-02 | 2008-06-23 |  | 0d |  |  |  | 208h |
| 24 | 2.1.3.1 | Specify and order cameras ( Coordinate with WHOI) | 4d? | 2008-05-02 | 2008-05-07 | 19 | 0d |  |  | EE1 [50%] | 16h |
| 25 | 2.1.3.2 | Specify and order strobes | 8d? | 2008-05-08 | 2008-05-19 | 24 | 0d |  |  | EE2 [50%] | 32h |
| 26 | 2.1.3.3 | Design mounting brackets for cameras and strobes | 2d? | 2008-05-20 | 2008-05-21 | 25 | 0d |  |  | ME | 16h |
| 27 | 2.1.3.4 | specify and order strobe j-box connectors | 1d? | 2008-05-22 | 2008-05-22 | 16, 26 | 0d |  |  | ME | 8h |
| 28 | 2.1.3.5 | Fabricate strobe j-boxes | 2d? | 2008-05-23 | 2008-05-26 | 27 | 106d | 0d |  | CIP Machinist | 16h |
| 29 | 2.1.3.6 | Develop camera interface | 10d? | 2008-05-27 | 2008-06-09 | 28 | 106d | 0d |  | EE1 [50%] | 40h |
| 30 | 2.1.3.7 | wire up and test | 5d? | 2008-06-10 | 2008-06-16 | 29 | 106d | 0d |  | CIP EE Tech | 40h |
| 31 | 2.1.3.8 | assemble and install j-box connectors | 5d? | 2008-06-17 | 2008-06-23 | 30 | 106d |  |  | CIP EE Tech | 40h |

| ID | WBS | Task | Duration | Start | Finish | Predecessors | Total slack | Free slack | Resources | Work |
| --- | --- | --- | --- | --- | --- | --- | --- | --- | --- | --- |
| 32 | 2.1.4 | **Sed. Sensor (2 units)** | 62d? | 2008-05-23 | 2008-08-18 |  | 0d |  |  | 368h |
| 33 | 2.1.4.1 | Order (2) McLane Parfluxs | 2d? | 2008-05-23 | 2008-05-26 | 27 | 0d |  | ME [50%] | 8h |
| 34 | 2.1.4.2 | McLane fabrication | 60d | 2008-05-27 | 2008-08-18 | 33 | 66d |  |  |  |
| 35 | 2.1.4.3 | Specify camera and light | 5d? | 2008-05-27 | 2008-06-02 | 33 | 121d |  | ME | 40h |
| 36 | 2.1.4.4 | Order camera and light | 4d? | 2008-05-27 | 2008-05-30 | 33 | 0d |  | EE1 [50%] | 16h |
| 37 | 2.1.4.5 | Sed sensor mods (stepper, fluorometers, halls) | 10d? | 2008-06-02 | 2008-06-13 | 36 | 0d |  | EE2 [50%] | 40h |
| 38 | 2.1.4.6 | Sensor calibration and validation | 10d? | 2008-06-16 | 2008-06-27 | 37 | 0d |  | EE2 [50%] | 40h |
| 39 | 2.1.4.7 | Design imaging stage for Parflux | 10d? | 2008-06-30 | 2008-07-11 | 38 | 0d |  | ME | 80h |
| 40 | 2.1.4.8 | Fabricate imaging stage components (~6 parts) | 3d? | 2008-07-14 | 2008-07-16 | 39 | 69d | 0d | CIP Machinist | 24h |
| 41 | 2.1.4.9 | Build Sed. Sensor | 10d? | 2008-07-17 | 2008-07-30 | 40 | 69d | 0d | CIP ME Tech | 80h |
| 42 | 2.1.4.10 | Wire up and test | 10d? | 2008-07-31 | 2008-08-13 | 41 | 69d |  | EE2 [50%] | 40h |
| 43 | 2.2 | **Benthic Cable** | 73d? | 2008-07-14 | 2008-10-22 |  | 0d |  |  | 224h |
| 44 | 2.2.1 | Design winch | 10d? | 2008-07-14 | 2008-07-25 | 39 | 0d |  | ME | 80h |
| 45 | 2.2.2 | order material | 1d? | 2008-07-28 | 2008-07-28 | 44 | 0d |  | ME | 8h |
| 46 | 2.2.3 | order ODI connector and cable | 1d? | 2008-07-29 | 2008-07-29 | 45 | 0d |  | ME | 8h |
| 47 | 2.2.4 | order football floats | 1d? | 2008-07-30 | 2008-07-30 | 46 | 0d |  | ME | 8h |
| 48 | 2.2.5 | connector and cable fabrication | 60d | 2008-07-31 | 2008-10-22 | 47 | 19d |  |  |  |
| 49 | 2.2.6 | waterjet plates | 2d? | 2008-07-31 | 2008-08-01 | 47 | 64d | 0d | CIP Machinist | 16h |
| 50 | 2.2.7 | cut drum | 1d? | 2008-08-04 | 2008-08-04 | 49 | 64d | 0d | CIP Machinist | 8h |
| 51 | 2.2.8 | fabricate winch | 8d? | 2008-08-05 | 2008-08-14 | 50 | 64d | 0d | CIP Machinist | 64h |
| 52 | 2.2.9 | Assemble and test winch | 4d? | 2008-08-15 | 2008-08-20 | 51 | 64d |  | CIP ME Tech | 32h |
| 53 | 2.3 | **Riser Cable** | 61d? | 2008-07-31 | 2008-10-23 |  | 0d |  |  | 104h |
| 54 | 2.3.1 | Specify and order cable | 1d? | 2008-07-31 | 2008-07-31 | 47 | 0d |  | ME | 8h |
| 55 | 2.3.2 | fabricate and ship cable | 60d | 2008-08-01 | 2008-10-23 | 54 | 18d |  |  |  |
| 56 | 2.3.3 | design mechanical terminations with slip rings | 7d? | 2008-08-01 | 2008-08-11 | 54 | 0d |  | ME | 56h |
| 57 | 2.3.4 | fabricate mech. Term. | 2d? | 2008-08-12 | 2008-08-13 | 56 | 66d | 0d | CIP Machinist | 16h |
| 58 | 2.3.5 | install slip rings | 3d? | 2008-08-14 | 2008-08-18 | 57 | 66d |  | CIP ME Tech | 24h |

| ID | WBS | Task | Duration | Start | Finish | Predecessors | Total slack | Resources | Work |
| --- | --- | --- | --- | --- | --- | --- | --- | --- | --- |
| 59 | 2.4 | **Pelagic Platform** | 71d? | 2008-08-12 | 2008-11-18 |  | 0d |  | 80h |
| 60 | 2.4.1 | Design Pelagic Platform | 6d? | 2008-08-12 | 2008-08-19 | 56 | 0d | ME | 48h |
| 61 | 2.4.2 | Specify and order cable | 1d? | 2008-08-20 | 2008-08-20 | 60 | 0d | ME | 8h |
| 62 | 2.4.3 | cable fabrication and shipping | 60d | 2008-08-21 | 2008-11-12 | 61 | 4d |  |  |
| 63 | 2.4.4 | Specify and order slip rings | 1d? | 2008-08-21 | 2008-08-21 | 61 | 0d | ME | 8h |
| 64 | 2.4.5 | slip ring fabrication and shipping | 60d | 2008-08-22 | 2008-11-13 | 63 | 3d |  |  |
| 65 | 2.4.6 | Specify and order syntatic floam module | 1d? | 2008-08-22 | 2008-08-22 | 63 | 0d | ME | 8h |
| 66 | 2.4.7 | fabricate and ship syntatic foam module | 1d? | 2008-08-25 | 2008-08-25 | 65 | 0d |  |  |
| 67 | 2.4.8 | specify and order ODI connectors | 1d? | 2008-08-26 | 2008-08-26 | 65, 66 | 0d | ME | 8h |
| 68 | 2.4.9 | fabricate and ship ODI connectors | 60d | 2008-08-27 | 2008-11-18 | 67 | 0d |  |  |
