# Year 2 NSF

Schedule from MS Project, 2007-02-12 to 2007-08-30.
MBARI

## Calendars

- Standard: Mon-Fri 08:00-12:00, 13:00-17:00; Sat-Sun off.

## Resources

| Resource |
| --- |
| ME |
| CIP Machinist |
| SE |
| ME Tech |
| EE2 |
| EE1 |

## Schedule

| ID | WBS | Task | Duration | Start | Finish | Predecessors | Total slack | Resources | Work |
| --- | --- | --- | --- | --- | --- | --- | --- | --- | --- |
| 1 | 1 | **Year 2 NSF** | 144d? | 2007-02-12 | 2007-08-30 |  | 0d |  | 1784h |
| 2 | 1.1 | fabricate PV | 5d? | 2007-02-12 | 2007-02-16 |  | 0d | CIP Machinist | 40h |
| 3 | 1.2 | fabricate platform frame | 10d? | 2007-02-19 | 2007-03-02 | 2 | 0d | CIP Machinist | 80h |
| 4 | 1.3 | install Sed sensor, PV, foam, slip ring | 12d? | 2007-03-05 | 2007-03-20 | 3 | 0d | ME Tech | 96h |
| 5 | 1.4 | Design pelagic platform electronics | 20d? | 2007-03-21 | 2007-04-17 | 4 | 0d | EE2 [50%] | 80h |
| 6 | 1.5 | specify and order electrical components | 2d? | 2007-04-18 | 2007-04-19 | 5 | 0d | EE1 [50%] | 8h |
| 7 | 1.6 | specify and order U/W connectors | 2d? | 2007-04-20 | 2007-04-23 | 6 | 0d | EE1 [50%] | 8h |
| 8 | 1.7 | fabricate and ship U/W connectors | 30d | 2007-04-24 | 2007-06-04 | 7 | 0d |  |  |
| 9 | 1.8 | assemble pelagic platform | 20d? | 2007-06-05 | 2007-07-02 | 8 | 0d | ME Tech | 160h |
| 10 | 1.9 | **Test and integration** | 43d? | 2007-07-03 | 2007-08-30 | 9 | 0d |  | 1312h |
| 11 | 1.9.1 | **Tank testing** | 15d? | 2007-07-03 | 2007-07-23 |  | 0d |  | 360h |
| 12 | 1.9.1.1 | ME tasks | 10d? | 2007-07-03 | 2007-07-16 |  | 5d | ME | 80h |
| 13 | 1.9.1.2 | EE tasks | 10d? | 2007-07-03 | 2007-07-16 |  | 5d | EE1 [50%]; EE2 [50%] | 80h |
| 14 | 1.9.1.3 | SE tasks | 10d? | 2007-07-03 | 2007-07-16 |  | 5d | SE | 80h |
| 15 | 1.9.1.4 | Tech tasks | 15d? | 2007-07-03 | 2007-07-23 |  | 0d | ME Tech | 120h |
| 16 | 1.9.2 | **Deploy on MARS 1** | 5d? | 2007-07-24 | 2007-07-30 | 11 | 0d |  | 160h |
| 17 | 1.9.2.1 | ME tasks | 5d? | 2007-07-24 | 2007-07-30 |  | 0d | ME | 40h |
| 18 | 1.9.2.2 | EE tasks | 5d? | 2007-07-24 | 2007-07-30 |  | 0d | EE1 [50%]; EE2 [50%] | 40h |
| 19 | 1.9.2.3 | SE tasks | 5d? | 2007-07-24 | 2007-07-30 |  | 0d | SE | 40h |
| 20 | 1.9.2.4 | Tech tasks | 5d? | 2007-07-24 | 2007-07-30 |  | 0d | ME Tech | 40h |
| 21 | 1.9.3 | **Deploy on MARS 2** | 5d? | 2007-07-31 | 2007-08-06 | 16 | 0d |  | 160h |
| 22 | 1.9.3.1 | ME tasks | 5d? | 2007-07-31 | 2007-08-06 |  | 0d | ME | 40h |
| 23 | 1.9.3.2 | EE tasks | 5d? | 2007-07-31 | 2007-08-06 |  | 0d | EE1 [50%]; EE2 [50%] | 40h |
| 24 | 1.9.3.3 | SE tasks | 5d? | 2007-07-31 | 2007-08-06 |  | 0d | SE | 40h |
| 25 | 1.9.3.4 | Tech tasks | 5d? | 2007-07-31 | 2007-08-06 |  | 0d | ME Tech | 40h |

| ID | WBS | Task | Duration | Start | Finish | Predecessors | Total slack | Resources | Work |
| --- | --- | --- | --- | --- | --- | --- | --- | --- | --- |
| 26 | 1.9.4 | **Deploy on Aloha 1** | 18d? | 2007-08-07 | 2007-08-30 | 21 | 0d |  | 632h |
| 27 | 1.9.4.1 | **ME tasks** | 18d? | 2007-08-07 | 2007-08-30 |  | 0d |  | 168h |
| 28 | 1.9.4.1.1 | Travel to WHOI to plan with Jason | 3d? | 2007-08-07 | 2007-08-09 |  | 15d | ME | 24h |
| 29 | 1.9.4.1.2 | Travel to HA to deploy | 18d? | 2007-08-07 | 2007-08-30 |  | 0d | ME | 144h |
| 30 | 1.9.4.2 | **EE tasks** | 18d? | 2007-08-07 | 2007-08-30 |  | 0d |  | 312h |
| 31 | 1.9.4.2.1 | Travel to HA to plan with Aloha | 3d? | 2007-08-07 | 2007-08-09 |  | 15d | EE1 | 24h |
| 32 | 1.9.4.2.2 | Travel to HA to deploy | 18d | 2007-08-07 | 2007-08-30 |  | 0d | EE1; EE2 | 288h |
| 33 | 1.9.4.3 | SE tasks | 18d? | 2007-08-07 | 2007-08-30 |  | 0d | SE | 144h |
| 34 | 1.9.4.4 | Tech tasks | 1d? | 2007-08-07 | 2007-08-07 |  | 17d | ME Tech | 8h |
